# 太湖桃花江箱涵施工进度

Schedule from MS Project, 2003-06-28 to 2003-10-15.
dj

## Calendars

- 标准: Mon-Sun 08:00-12:00, 13:00-17:00.

## Schedule

| ID | Task | Duration | Start | Finish | Predecessors | Total slack |
| --- | --- | --- | --- | --- | --- | --- |
| 1 | 场地清理及测量放线 | 10ed | 2003-06-28 | 2003-07-08 |  | 0d |
| 2 | 基坑开挖及基坑排水 | 10ed | 2003-07-08 | 2003-07-18 | 1 | 0d |
| 3 | 基底清理及人造硬壳层 | 19ed | 2003-07-18 | 2003-08-06 | 2 | 0d |
| 4 | 箱涵底板布筋、立模、浇砼 | 15ed | 2003-08-06 | 2003-08-21 | 3 | 0d |
| 5 | 箱涵侧墙及顶板布筋、立模、浇砼 | 25ed | 2003-08-21 | 2003-09-15 | 4 | 0d |
| 6 | 防水层及沉降缝处理 | 5ed | 2003-09-15 | 2003-09-20 | 5 | 0d |
| 7 | 端翼墙施工及洞口处理 | 33ed | 2003-08-15 | 2003-09-17 | 3FS+10d | 7.88d |
| 8 | 箱 涵 回 填 | 15ed | 2003-09-20 | 2003-10-05 | 7, 6 | 0d |
| 9 | 工 程 收 尾 | 10ed | 2003-10-05 | 2003-10-15 | 8 | 0d |
